# MoveOfficeExporting

Schedule from MS Project, 2010-01-04 to 2010-02-05, status date 2010-01-28, costs in $, A marks actual dates.
Microsoft

## Calendars

- Standard: Mon-Fri 08:00-12:00, 13:00-17:00; Sat-Sun off.

## Schedule

| ID | WBS | Task | Type | Duration | Start | Finish | Predecessors | Complete | Remaining | Baseline start | Baseline finish | Baseline duration | Total slack | Constraint | Deadline | Cost | Baseline cost | Actual cost |
| --- | --- | --- | --- | --- | --- | --- | --- | --- | --- | --- | --- | --- | --- | --- | --- | --- | --- | --- |
| 1 | 1 | **Progress Meeting** |  | 20.12d | 2010-01-04 08:00 A | 2010-02-01 09:00 |  | 80% | 4.03d | 2010-01-04 08:00 | 2010-02-01 09:00 | 20.12d | 0d |  |  |  |  |  |
| 2 | 1.1 | Progress Meeting 1 | manual | 1h | 2010-01-04 08:00 A | 2010-01-04 09:00 A |  | 100% |  | 2010-01-04 08:00 | 2010-01-04 09:00 | 1h |  | start no earlier than 2010-01-04 08:00 |  |  |  |  |
| 3 | 1.2 | Progress Meeting 2 | manual | 1h | 2010-01-11 08:00 A | 2010-01-11 09:00 A |  | 100% |  | 2010-01-11 08:00 | 2010-01-11 09:00 | 1h |  | start no earlier than 2010-01-11 08:00 |  |  |  |  |
| 4 | 1.3 | Progress Meeting 3 | manual | 1h | 2010-01-18 08:00 A | 2010-01-18 09:00 A |  | 100% |  | 2010-01-18 08:00 | 2010-01-18 09:00 | 1h |  | start no earlier than 2010-01-18 08:00 |  |  |  |  |
| 5 | 1.4 | Progress Meeting 4 | manual | 1h | 2010-01-25 08:00 A | 2010-01-25 09:00 A |  | 100% |  | 2010-01-25 08:00 | 2010-01-25 09:00 | 1h |  | start no earlier than 2010-01-25 08:00 |  |  |  |  |
| 6 | 1.5 | Progress Meeting 5 | manual | 1h | 2010-02-01 08:00 | 2010-02-01 09:00 |  |  |  | 2010-02-01 08:00 | 2010-02-01 09:00 | 1h |  | start no earlier than 2010-02-01 08:00 |  |  |  |  |
| 7 | 2 | **Pre-work** |  | 5.25d | 2010-01-04 08:00 A | 2010-01-11 10:00 A |  | 100% |  | 2010-01-04 08:00 | 2010-01-07 14:00 | 3.62d |  |  |  |  |  |  |
| 8 | 2.1 | Get Fit-out quotes |  | 2d | 2010-01-04 08:00 A | 2010-01-05 17:00 A |  | 100% |  | 2010-01-04 08:00 | 2010-01-05 17:00 | 2d |  |  |  |  |  |  |
| 9 | 2.2 | Get Moving Company Quotes |  | 1d | 2010-01-06 08:00 A | 2010-01-06 17:00 A | 8 | 100% |  | 2010-01-06 08:00 | 2010-01-06 17:00 | 1d |  |  |  |  |  |  |
| 10 | 2.3 | Evaluate and Accept Quotes |  | 5h | 2010-01-07 08:00 A | 2010-01-07 14:00 A | 9 | 100% |  | 2010-01-07 08:00 | 2010-01-07 11:00 | 3h |  |  |  |  |  |  |
| 11 | 2.4 | Confirm Moving Day |  | 2h | 2010-01-11 08:00 A | 2010-01-11 10:00 A | 10 | 100% |  | 2010-01-07 11:00 | 2010-01-07 14:00 | 2h |  | finish no later than 2010-01-08 17:00 | 2010-01-08 17:00 |  |  |  |
| 12 | 3 | **Fit Out New Premises** |  | 7.5d | 2010-01-11 10:00 A | 2010-01-20 15:00 A | 7 | 100% |  | 2010-01-07 14:00 | 2010-01-19 09:00 | 7.5d |  |  |  | 10,100 | 10,100 | 10,100 |
| 13 | 3.1 | Power |  | 0.5d | 2010-01-11 10:00 A | 2010-01-11 15:00 A |  | 100% |  | 2010-01-07 14:00 | 2010-01-08 09:00 | 0.5d |  |  |  | 100 | 100 | 100 |
| 14 | 3.2 | Cabling |  | 4d | 2010-01-11 15:00 A | 2010-01-15 15:00 A | 13 | 100% |  | 2010-01-08 09:00 | 2010-01-14 09:00 | 4d |  |  |  | 5,000 | 5,000 | 5,000 |
| 15 | 3.3 | Decorating |  | 1w | 2010-01-13 15:00 A | 2010-01-20 15:00 A | 14FS-5% | 100% |  | 2010-01-12 09:00 | 2010-01-19 09:00 | 1w |  |  |  | 5,000 | 5,000 | 5,000 |
| 16 | 4 | **Packing** |  | 6d | 2010-01-20 15:00 A | 2010-01-28 15:00 A | 12 | 100% |  | 2010-01-19 09:00 | 2010-01-27 09:00 | 6d |  |  |  | 100 | 100 | 100 |
| 17 | 4.1 | Get Boxes |  | 1d | 2010-01-20 15:00 A | 2010-01-21 15:00 A |  | 100% |  | 2010-01-19 09:00 | 2010-01-20 09:00 | 1d |  |  |  | 100 | 100 | 100 |
| 18 | 4.2 | Pack boxes |  | 1w | 2010-01-21 15:00 A | 2010-01-28 15:00 A | 17 | 100% |  | 2010-01-20 09:00 | 2010-01-27 09:00 | 1w |  |  |  |  |  |  |
| 19 | 4.3 | Make Inventory |  | 1w | 2010-01-21 15:00 A | 2010-01-28 15:00 A | 18SS | 100% |  | 2010-01-20 09:00 | 2010-01-27 09:00 | 1w |  |  |  |  |  |  |
| 20 | 5 | Transport Boxes |  | 1ed | 2010-01-28 15:00 A | 2010-01-29 15:00 | 16 | 8% | 0.92ed | 2010-01-27 09:00 | 2010-01-28 09:00 | 1ed | 0d |  |  |  |  |  |
| 21 | 6 | **Unpacking** |  | 5d | 2010-01-29 15:00 | 2010-02-05 15:00 | 20 |  |  | 2010-01-28 09:00 | 2010-02-04 09:00 | 5d | 0d |  |  |  |  |  |
| 22 | 6.1 | Unpack Boxes |  | 1w | 2010-01-29 15:00 | 2010-02-05 15:00 |  |  |  | 2010-01-28 09:00 | 2010-02-04 09:00 | 1w | 0d |  |  |  |  |  |
| 23 | 6.2 | Install Equipment |  | 1w | 2010-01-29 15:00 | 2010-02-05 15:00 | 22FF |  |  | 2010-01-28 09:00 | 2010-02-04 09:00 | 1w | 0d |  |  |  |  |  |
| 24 | 6.3 | Check Inventory |  | 1w | 2010-01-29 15:00 | 2010-02-05 15:00 | 23FF |  |  | 2010-01-28 09:00 | 2010-02-04 09:00 | 1w | 0d |  |  |  |  |  |
| 25 | 7 | Move In | milestone | 0d | 2010-02-05 15:00 | 2010-02-05 15:00 | 21 |  |  | 2010-02-04 09:00 | 2010-02-04 09:00 | 0d | 0d |  |  |  |  |  |
