# MoveOfficeReporting

Schedule from MS Project, 2013-01-07 to 2013-02-22, status date 2013-01-31, costs in $, A marks actual dates.
Microsoft

## Calendars

- Standard: Mon-Fri 08:00-12:00, 13:00-17:00; Sat-Sun off.

## Schedule

| ID | WBS | Task | Type | Duration | Start | Finish | Predecessors | Complete | Remaining | Baseline start | Baseline finish | Baseline duration | Total slack | Constraint | Deadline | Cost | Baseline cost | Actual cost |
| --- | --- | --- | --- | --- | --- | --- | --- | --- | --- | --- | --- | --- | --- | --- | --- | --- | --- | --- |
| 1 | 1 | **Pre-work** |  | 5.25d | 2013-01-07 A | 2013-01-14 A |  | 100% |  | 2013-01-07 | 2013-01-10 | 3.62d |  |  |  |  |  |  |
| 2 | 1.1 | Get Fit-out quotes |  | 2d | 2013-01-07 A | 2013-01-08 A |  | 100% |  | 2013-01-07 | 2013-01-08 | 2d |  |  |  |  |  |  |
| 3 | 1.2 | Get Moving Company Quotes |  | 1d | 2013-01-09 A | 2013-01-09 A | 2 | 100% |  | 2013-01-09 | 2013-01-09 | 1d |  |  |  |  |  |  |
| 4 | 1.3 | Evaluate and Accept Quotes |  | 5h | 2013-01-10 A | 2013-01-10 A | 3 | 100% |  | 2013-01-10 | 2013-01-10 | 3h |  |  |  |  |  |  |
| 5 | 1.4 | Confirm Moving Day |  | 2h | 2013-01-14 A | 2013-01-14 A | 4 | 100% |  | 2013-01-10 | 2013-01-10 | 2h |  | finish no later than 2013-01-11 | 2013-01-11 |  |  |  |
| 6 | 2 | **Fit Out New Premises** |  | 7.5d | 2013-01-14 A | 2013-01-23 A | 1 | 100% |  | 2013-01-10 | 2013-01-22 | 7.5d |  |  |  | 10,100 | 10,100 | 10,100 |
| 7 | 2.1 | Power |  | 0.5d | 2013-01-14 A | 2013-01-14 A |  | 100% |  | 2013-01-10 | 2013-01-11 | 0.5d |  |  |  | 100 | 100 | 100 |
| 8 | 2.2 | Cabling |  | 4d | 2013-01-14 A | 2013-01-18 A | 7 | 100% |  | 2013-01-11 | 2013-01-17 | 4d |  |  |  | 5,000 | 5,000 | 5,000 |
| 9 | 2.3 | Decorating |  | 1w | 2013-01-16 A | 2013-01-23 A | 8FS-5% | 100% |  | 2013-01-15 | 2013-01-22 | 1w |  |  |  | 5,000 | 5,000 | 5,000 |
| 10 | 3 | **Packing** |  | 6d | 2013-01-23 A | 2013-01-31 A | 6 | 100% |  | 2013-01-22 | 2013-01-30 | 6d |  |  |  | 100 | 100 | 100 |
| 11 | 3.1 | Get Boxes |  | 1d | 2013-01-23 A | 2013-01-24 A |  | 100% |  | 2013-01-22 | 2013-01-23 | 1d |  |  |  | 100 | 100 | 100 |
| 12 | 3.2 | Pack boxes |  | 1w | 2013-01-24 A | 2013-01-31 A | 11 | 100% |  | 2013-01-23 | 2013-01-30 | 1w |  |  |  |  |  |  |
| 13 | 3.3 | Make Inventory |  | 1w | 2013-01-24 A | 2013-01-31 A | 12SS | 100% |  | 2013-01-23 | 2013-01-30 | 1w |  |  |  |  |  |  |
| 14 | 4 | Transport Boxes |  | 1ed | 2013-01-31 A | 2013-02-01 | 10 | 8% | 0.92ed | 2013-01-30 | 2013-01-31 | 1ed | 0d |  |  |  |  |  |
| 15 | 5 | **Unpacking** |  | 15d | 2013-02-01 | 2013-02-22 | 14 |  |  | 2013-01-31 | 2013-02-21 | 15d | 0d |  |  |  |  |  |
| 16 | 5.1 | Unpack Boxes |  | 1w | 2013-02-01 | 2013-02-08 |  |  |  | 2013-01-31 | 2013-02-07 | 1w | 0d |  |  |  |  |  |
| 17 | 5.2 | Install Equipment |  | 1w | 2013-02-08 | 2013-02-15 | 16 |  |  | 2013-02-07 | 2013-02-14 | 1w | 0d |  |  |  |  |  |
| 18 | 5.3 | Check Inventory |  | 1w | 2013-02-15 | 2013-02-22 | 17 |  |  | 2013-02-14 | 2013-02-21 | 1w | 0d |  |  |  |  |  |
| 19 | 6 | Move In | milestone | 0d | 2013-02-22 | 2013-02-22 | 15 |  |  | 2013-02-21 | 2013-02-21 |  | 0d |  |  |  |  |  |
