# MoveOfficeTracking

Schedule from MS Project, 2013-01-07 to 2013-02-21.
Microsoft

## Calendars

- Standard: Mon-Fri 08:00-12:00, 13:00-17:00; Sat-Sun off.

## Schedule

| ID | WBS | Task | Type | Duration | Start | Finish | Predecessors | Total slack | Constraint | Deadline |
| --- | --- | --- | --- | --- | --- | --- | --- | --- | --- | --- |
| 1 | 1 | **Pre-work** |  | 3.62d | 2013-01-07 | 2013-01-10 |  | 0d |  |  |
| 2 | 1.1 | Get Fit-out quotes |  | 2d | 2013-01-07 | 2013-01-08 |  | 0d |  |  |
| 3 | 1.2 | Get Moving Company Quotes |  | 1d | 2013-01-09 | 2013-01-09 | 2 | 0d |  |  |
| 4 | 1.3 | Evaluate and Accept Quotes |  | 3h | 2013-01-10 | 2013-01-10 | 3 | 0d |  |  |
| 5 | 1.4 | Confirm Moving Day |  | 2h | 2013-01-10 | 2013-01-10 | 4 | 0d | finish no later than 2013-01-11 | 2013-01-11 |
| 6 | 2 | **Fit Out New Premises** |  | 7.5d | 2013-01-10 | 2013-01-22 | 1 | 0d |  |  |
| 7 | 2.1 | Power |  | 0.5d | 2013-01-10 | 2013-01-11 |  | 0d |  |  |
| 8 | 2.2 | Cabling |  | 4d | 2013-01-11 | 2013-01-17 | 7 | 0d |  |  |
| 9 | 2.3 | Decorating |  | 1w | 2013-01-15 | 2013-01-22 | 8FS-5% | 0d |  |  |
| 10 | 3 | **Packing** |  | 6d | 2013-01-22 | 2013-01-30 | 6 | 0d |  |  |
| 11 | 3.1 | Get Boxes |  | 1d | 2013-01-22 | 2013-01-23 |  | 0d |  |  |
| 12 | 3.2 | Pack boxes |  | 1w | 2013-01-23 | 2013-01-30 | 11 | 0d |  |  |
| 13 | 3.3 | Make Inventory |  | 1w | 2013-01-23 | 2013-01-30 | 12SS | 0d |  |  |
| 14 | 4 | Transport Boxes |  | 1ed | 2013-01-30 | 2013-01-31 | 10 | 0d |  |  |
| 15 | 5 | **Unpacking** |  | 15d | 2013-01-31 | 2013-02-21 | 14 | 0d |  |  |
| 16 | 5.1 | Unpack Boxes |  | 1w | 2013-01-31 | 2013-02-07 |  | 0d |  |  |
| 17 | 5.2 | Install Equipment |  | 1w | 2013-02-07 | 2013-02-14 | 16 | 0d |  |  |
| 18 | 5.3 | Check Inventory |  | 1w | 2013-02-14 | 2013-02-21 | 17 | 0d |  |  |
| 19 | 6 | Move In | milestone | 0d | 2013-02-21 | 2013-02-21 | 15 | 0d |  |  |
